# Woods Family 3BR Home

Schedule from MS Project, 2016-05-02 to 2016-12-30, status date 2016-09-23, costs in $.
Residential Construction
Building with Heart
Clear debris. Two girls. Greene City Interiors for finishing.

## Calendars

- BWH Standard Calendar: Mon-Fri 08:00-12:00, 13:00-17:00; Sat-Sun off. Exceptions (off unless hours are given): 2016-05-23 to 2025-05-26 (Memorial Day, recurring), 2016-07-04 (Independence Day), 2016-09-05 (Labor Day), 2016-11-08 08:00-12:00 (Election Day), 2016-11-24 (Thanksgiving Day), 2016-11-25 (Black Friday), 2016-12-26 (Christmas Day (observed)).

## Resources

| Resource | Unit | Rate |
| --- | --- | --- |
| Concrete contractor |  |  |
| Finish carpentry contractor |  |  |
| Fencing contractor |  |  |
| Masonry contractor |  |  |
| General contractor |  |  |
| Architect |  |  |
| Owner |  |  |
| Mortgage lender |  |  |
| Inspector |  |  |
| Electric company |  |  |
| Site excavation contractor |  |  |
| Electric contractor |  |  |
| Plumbing contractor |  |  |
| Framing contractor |  |  |
| Roofing contractor |  |  |
| Heating and AC contractor |  |  |
| Insulation contractor |  |  |
| Drywall contractor |  |  |
| Painting contractor |  |  |
| Flooring contractor |  |  |
| Appliance contractor |  |  |
| Gary Clark |  |  |
| Maid service |  | 40 |
| Volunteer 1 |  |  |
| Volunteer 2 |  |  |
| Volunteer 3 |  |  |
| Volunteer 4 |  |  |
| Container |  | 2.5 |
| Waste Dump Fee | ton | 150 |
| Construction Fixed Cost |  |  |
| Project Budget |  |  |

## Schedule

| ID | WBS | Task | Type | Duration | Start | Finish | Predecessors | Total slack | Free slack | Constraint | Resources | Work | Cost |
| --- | --- | --- | --- | --- | --- | --- | --- | --- | --- | --- | --- | --- | --- |
| 1 | 1 | **General Conditions** |  | 45d? | 2016-05-02 | 2016-07-05 |  | -4.5d | 0d |  | Construction Fixed Cost [0.1%] | 569.2h | 184,850 |
| 2 | 1.1 | Finalize plans and develop estimate with owner, architect |  | 10d | 2016-05-02 | 2016-05-13 |  | 0d |  |  | General contractor [50%]; Architect [50%]; Owner [12%]; Mortgage lender [12%] | 99.2h |  |
| 3 | 1.2 | Sign contract and notice to proceed |  | 1d | 2016-05-16 | 2016-05-16 | 2 | 0d |  |  | General contractor; Architect; Owner; Mortgage lender | 32h |  |
| 4 | 1.3 | **Clear Old Home** |  | 24d? | 2016-06-01 | 2016-07-05 |  | -4.5d | 0d |  |  | 438h | 4,850 |
| 5 | 1.3.1 | Demolition of Old House |  | 2w? | 2016-06-01 | 2016-06-14 | 3FS+2w | 7.5d | 0d |  | Site excavation contractor | 80h |  |
| 6 | 1.3.2 | Place Containers |  | 1d | 2016-06-01 | 2016-06-01 | 5SS | 11.44d | 3.94d |  | Container [300%]; Volunteer 4 | 24h | 40 |
| 7 | 1.3.3 | Sort Debris |  | 6.06d | 2016-06-07 | 2016-06-15 | 6, 5FF+1d | 7.5d | 0d |  | Volunteer 1; Volunteer 2; Volunteer 3; Volunteer 4; Container [300%] | 302h | 270 |
| 8 | 1.3.4 | Haul Recycling |  | 1d | 2016-07-05 | 2016-07-05 | 7 | -4.5d | 0d | start no earlier than 2016-07-05 | Container; Volunteer 4 | 16h | 20 |
| 9 | 1.3.5 | Haul Waste |  | 1d | 2016-06-16 | 2016-06-16 | 7 | 7.5d |  |  | Container; Volunteer 4; Waste Dump Fee [30 ton] | 16h | 4,520 |
| 10 | 1.4 | **Apply for Permits** |  | 0d | 2016-05-16 | 2016-05-16 |  | 0d |  |  |  |  |  |
| 11 | 1.4.1 | Secure foundation permit | milestone | 0d | 2016-05-16 | 2016-05-16 | 3 | 0d |  |  | General contractor |  |  |
| 12 | 1.4.2 | Secure framing permit | milestone | 0d | 2016-05-16 | 2016-05-16 | 3 | 0d |  |  | General contractor |  |  |
| 13 | 1.4.3 | Secure electrical permit | milestone | 0d | 2016-05-16 | 2016-05-16 | 3 | 0d |  |  | General contractor |  |  |
| 14 | 1.4.4 | Secure plumbing permit | milestone | 0d | 2016-05-16 | 2016-05-16 | 3 | 0d |  |  | General contractor |  |  |
| 15 | 1.4.5 | Secure HVAC permit | milestone | 0d | 2016-05-16 | 2016-05-16 | 3 | 0d |  |  | General contractor |  |  |
| 16 | 1.4.6 | Secure miscellaneous permits | milestone | 0d | 2016-05-16 | 2016-05-16 | 3 | 0d |  |  | General contractor |  |  |
| 17 | 2 | **Site Work** |  | 3d | 2016-07-06 | 2016-07-08 |  | -4.5d | 0d |  |  | 32h |  |
| 18 | 2.1 | Clear and grub lot |  | 1d | 2016-07-06 | 2016-07-06 | 11, 12, 13, 14, 16, 15, 8, 9 | -4.5d | 0d |  | Site excavation contractor | 8h |  |
| 19 | 2.2 | Install temporary power service |  | 1d | 2016-07-07 | 2016-07-07 | 18 | -4.5d | 0d |  | Electric company | 8h |  |
| 20 | 2.3 | Install underground utilities |  | 1d | 2016-07-08 | 2016-07-08 | 19 | -4.5d | 0d |  | Electric contractor; Plumbing contractor | 16h |  |
| 21 | 3 | **Foundation** |  | 27.5d | 2016-07-11 | 2016-08-17 |  | -4.5d | 0d |  |  | 280h |  |
| 22 | 3.1 | Excavate for foundations |  | 3d | 2016-07-11 | 2016-07-13 | 20 | -4.5d | 0d |  | Site excavation contractor | 24h |  |
| 23 | 3.2 | Form basement walls |  | 6.5d | 2016-07-14 | 2016-07-22 | 22 | -4.5d | 0d |  | Concrete contractor [200%] | 104h |  |
| 24 | 3.3 | Place concrete for foundations & basement walls |  | 6d | 2016-07-22 | 2016-08-01 | 23 | -4.5d | 0d |  | Concrete contractor [200%] | 96h |  |
| 25 | 3.4 | Cure basement walls for 7 days |  | 7d | 2016-08-01 | 2016-08-10 | 24 | -4.5d | 0d |  |  |  |  |
| 26 | 3.5 | Strip basement wall forms |  | 1d | 2016-08-10 | 2016-08-11 | 25 | -4.5d | 0d |  | Concrete contractor [200%] | 16h |  |
| 27 | 3.6 | Waterproof/insulate basement walls |  | 1d | 2016-08-11 | 2016-08-12 | 26 | -4.5d | 0d |  | Concrete contractor [200%] | 16h |  |
| 28 | 3.7 | Perform foundation inspection |  | 1d | 2016-08-12 | 2016-08-15 | 27, 22 | -4.5d | 0d |  | Inspector | 8h |  |
| 29 | 3.8 | Backfill foundation |  | 2d | 2016-08-15 | 2016-08-17 | 28 | -4.5d | 0d |  | Site excavation contractor | 16h |  |

| ID | WBS | Task | Type | Duration | Start | Finish | Predecessors | Total slack | Free slack | Constraint | Resources | Work |
| --- | --- | --- | --- | --- | --- | --- | --- | --- | --- | --- | --- | --- |
| 30 | 4 | **Framing** |  | 27.5d | 2016-08-17 | 2016-09-26 |  | -4.5d | 0d |  |  | 220h |
| 31 | 4.1 | Install 1st floor joists |  | 2d | 2016-08-17 | 2016-08-19 | 29 | -4.5d | 0d |  | Framing contractor | 16h |
| 32 | 4.2 | Lay 1st floor decking |  | 2d | 2016-08-19 | 2016-08-23 | 31 | -4.5d | 0d |  | Framing contractor | 16h |
| 33 | 4.3 | Frame 1st floor walls |  | 4d | 2016-08-23 | 2016-08-29 | 32 | -4.5d | 0d |  | Framing contractor | 32h |
| 34 | 4.4 | Frame 1st floor corners |  | 1d | 2016-08-29 | 2016-08-30 | 33 | -4.5d | 0d |  | Framing contractor | 8h |
| 35 | 4.5 | Install 2nd floor joists |  | 2d | 2016-08-30 | 2016-09-01 | 34 | -4.5d | 0d |  | Framing contractor | 16h |
| 36 | 4.6 | Frame 2nd floor decking |  | 2d | 2016-09-01 | 2016-09-06 | 35 | -4.5d | 0d |  | Framing contractor | 16h |
| 37 | 4.7 | Frame 2nd floor walls |  | 3d | 2016-09-06 | 2016-09-09 | 36 | -4.5d | 0d |  | Framing contractor | 24h |
| 38 | 4.8 | Frame 2nd floor corners |  | 5.5d | 2016-09-09 | 2016-09-16 | 37 | -4.5d | 0d |  | Framing contractor | 44h |
| 39 | 4.9 | Complete roof framing |  | 5d | 2016-09-19 | 2016-09-23 | 38 | -4.5d | 0d |  | Framing contractor | 40h |
| 40 | 4.10 | Conduct framing inspection |  | 1d | 2016-09-26 | 2016-09-26 | 39 | -4.5d | 0d |  | Inspector | 8h |
| 41 | 5 | **Dry In** |  | 25d | 2016-09-26 | 2016-10-28 |  | -4.5d | 0d |  |  | 152h |
| 42 | 5.1 | Install 1st floor sheathing |  | 3d | 2016-09-27 | 2016-09-29 | 40 | -4.5d | 0d |  | Framing contractor | 24h |
| 43 | 5.2 | Install 2nd floor sheathing |  | 3d | 2016-10-04 | 2016-10-06 | 42 | -4.5d | 0d |  | Framing contractor | 24h |
| 44 | 5.3 | Install roof decking |  | 3d | 2016-09-26 | 2016-10-03 | 39 | -1.5d | 0d |  | Framing contractor | 24h |
| 45 | 5.4 | Install felt, flashing and shingles |  | 3d | 2016-10-14 | 2016-10-18 | 54 | -4.5d | 0d |  | Roofing contractor | 24h |
| 46 | 5.5 | Install master bath skylight |  | 1d | 2016-10-19 | 2016-10-19 | 45 | -4.5d | 0d |  |  |  |
| 47 | 5.6 | Hang 1st floor exterior doors |  | 1d | 2016-10-20 | 2016-10-20 | 46 | -4.5d | 0d |  | Framing contractor | 8h |
| 48 | 5.7 | Install 1st floor windows |  | 3d | 2016-10-21 | 2016-10-25 | 47 | -4.5d | 0d |  | Framing contractor | 24h |
| 49 | 5.8 | Install 2nd floor windows |  | 3d | 2016-10-26 | 2016-10-28 | 48 | -4.5d | 0d |  | Framing contractor | 24h |
| 50 | 6 | **Exterior Finishes** |  | 19d | 2016-10-31 | 2016-11-29 |  | -4.5d | 0d |  |  | 152h |
| 51 | 6.1 | Complete exterior brick |  | 16d | 2016-10-31 | 2016-11-29 | 49 | -4.5d | 0d |  | Masonry contractor | 128h |
| 52 | 6.2 | Complete exterior siding | manual | 3d | 2016-11-21 | 2016-11-23 | 51 |  |  |  | Framing contractor | 24h |
| 53 | 7 | **Utility Rough-ins and Complete Concrete** |  | 21d | 2016-10-04 | 2016-11-01 |  | -1.5d | 0d |  |  | 232h |
| 54 | 7.1 | Rough-in plumbing |  | 5d | 2016-10-07 | 2016-10-13 | 44, 43 | -4.5d | 0d |  | Plumbing contractor | 40h |
| 55 | 7.2 | Conduct rough-in plumbing inspection |  | 1d | 2016-10-14 | 2016-10-14 | 54 | 25.5d | 0d |  | Inspector | 8h |
| 56 | 7.3 | Place concrete for basement floor |  | 5.5d | 2016-10-17 | 2016-10-24 | 55 | 38d | 26.5d |  | Concrete contractor [200%] | 88h |
| 57 | 7.4 | Rough-in electrical |  | 5d | 2016-10-07 | 2016-10-13 | 44, 43 | 12.5d | 8d |  | Electric contractor | 40h |
| 58 | 7.5 | Conduct rough-in electrical inspection |  | 1d | 2016-10-26 | 2016-10-26 | 57 | 4.5d | 0d | start no earlier than 2016-10-26 | Inspector | 8h |
| 59 | 7.6 | Rough-in HVAC |  | 3d | 2016-10-27 | 2016-10-31 | 58 | 4.5d | 0d |  | Heating and AC contractor | 24h |
| 60 | 7.7 | Conduct rough-in HVAC inspection |  | 1d | 2016-11-01 | 2016-11-01 | 59 | 21.5d | 17d |  | Inspector | 8h |
| 61 | 7.8 | Rough-in communication - phone, cable, computer, alarm |  | 2d | 2016-10-04 | 2016-10-05 | 44 | 22.5d | 18d |  | Electric contractor | 16h |

| ID | WBS | Task | Type | Duration | Start | Finish | Predecessors | Total slack | Free slack | Resources | Work |
| --- | --- | --- | --- | --- | --- | --- | --- | --- | --- | --- | --- |
| 62 | 8 | **Interior Finishes** |  | 29d | 2016-11-01 | 2016-12-14 |  | 4.5d |  |  | 400h |
| 63 | 8.1 | **Insulation** |  | 11.5d | 2016-11-01 | 2016-11-16 |  | 4.5d |  |  | 32h |
| 64 | 8.1.1 | Place wall insulation - 1st floor |  | 1d | 2016-11-01 | 2016-11-01 | 42, 49, 61, 59, 57, 43 | 4.5d | 0d | Insulation contractor | 8h |
| 65 | 8.1.2 | Place wall insulation - 2nd floor |  | 1d | 2016-11-02 | 2016-11-02 | 64 | 24.5d | 3d | Insulation contractor | 8h |
| 66 | 8.1.3 | Place ceiling insulation - 2nd floor |  | 1d | 2016-11-15 | 2016-11-15 | 72, 65 | 21d | 0d | Insulation contractor | 8h |
| 67 | 8.1.4 | Conduct insulation inspection |  | 1d | 2016-11-16 | 2016-11-16 | 66 | 21d | 9.5d | Inspector | 8h |
| 68 | 8.2 | **Drywall** |  | 9.5d | 2016-11-02 | 2016-11-15 |  | 4.5d |  |  | 80h |
| 69 | 8.2.1 | Install drywall - 1st floor walls |  | 2d | 2016-11-02 | 2016-11-03 | 64 | 4.5d | 0d | Drywall contractor | 16h |
| 70 | 8.2.2 | Install drywall - 1st floor overhead |  | 2d | 2016-11-04 | 2016-11-07 | 69 | 4.5d | 0d | Drywall contractor | 16h |
| 71 | 8.2.3 | Install drywall 2nd floor walls |  | 2d | 2016-11-09 | 2016-11-10 | 70, 65 | 21d | 0d | Drywall contractor | 16h |
| 72 | 8.2.4 | Install drywall 2nd floor overhead |  | 2d | 2016-11-11 | 2016-11-14 | 71 | 21d | 0d | Drywall contractor | 16h |
| 73 | 8.2.5 | Tape and float 1st floor drywall |  | 1d | 2016-11-08 | 2016-11-09 | 70 | 4.5d | 0d | Drywall contractor | 8h |
| 74 | 8.2.6 | Tape and float 2nd floor drywall |  | 1d | 2016-11-15 | 2016-11-15 | 72, 73 | 30d |  | Drywall contractor | 8h |
| 75 | 8.3 | **Paint and Wallpaper** |  | 14.5d | 2016-11-09 | 2016-12-01 |  | 4.5d |  |  | 64h |
| 76 | 8.3.1 | Texture all except entry and kitchen - 1st floor |  | 1d | 2016-11-09 | 2016-11-10 | 73 | 4.5d | 0d | Painting contractor | 8h |
| 77 | 8.3.2 | Paint all - 1st floor |  | 1d | 2016-11-10 | 2016-11-11 | 76 | 4.5d | 0d | Painting contractor | 8h |
| 78 | 8.3.3 | Hang wallpaper entry and kitchen - 1st floor | inactive | 1d | 2016-11-11 | 2016-11-14 | 77 | 3.5d | 0d | Painting contractor | 8h |
| 79 | 8.3.4 | Texture all - 2nd floor |  | 1d | 2016-11-14 | 2016-11-15 | 76 | 29.5d | 0d | Painting contractor | 8h |
| 80 | 8.3.5 | Paint all - 2nd floor |  | 1d | 2016-11-15 | 2016-11-16 | 79 | 29.5d |  | Painting contractor | 8h |
| 81 | 8.3.6 | Paint exterior siding & trim work |  | 4d | 2016-11-28 | 2016-12-01 | 52 | 0d |  | Painting contractor | 32h |
| 82 | 8.4 | **Cabinets** |  | 6d | 2016-11-11 | 2016-11-21 |  | 4.5d |  |  | 48h |
| 83 | 8.4.1 | Install 1st floor - kitchen cabinets |  | 2d | 2016-11-11 | 2016-11-15 | 78 | 4.5d | 0d | Finish carpentry contractor | 16h |
| 84 | 8.4.2 | Install 1st floor - master bath and guest cabinets |  | 1d | 2016-11-15 | 2016-11-16 | 83 | 4.5d | 0d | Finish carpentry contractor | 8h |
| 85 | 8.4.3 | Install 2nd floor - hall bath and private bath cabinets |  | 1d | 2016-11-16 | 2016-11-17 | 84 | 5.5d | 0d | Finish carpentry contractor | 8h |
| 86 | 8.4.4 | Install chair rails, crown moldings, trim |  | 2d | 2016-11-17 | 2016-11-21 | 85 | 18.5d | 7d | Finish carpentry contractor | 16h |

| ID | WBS | Task | Duration | Start | Finish | Predecessors | Total slack | Free slack | Resources | Work |
| --- | --- | --- | --- | --- | --- | --- | --- | --- | --- | --- |
| 87 | 8.5 | **Finish Plumbing** | 6d | 2016-11-15 | 2016-11-23 |  | 4.5d |  |  | 48h |
| 88 | 8.5.1 | Complete 1st floor - kitchen plumbing | 1d | 2016-11-15 | 2016-11-16 | 83, 55 | 4.5d | 0d | Plumbing contractor | 8h |
| 89 | 8.5.2 | Complete 1st floor - master bath and guest plumbing | 2d | 2016-11-16 | 2016-11-18 | 88, 84 | 4.5d | 0d | Plumbing contractor | 16h |
| 90 | 8.5.3 | Complete 2nd floor - hall bath and private bath plumbing | 2d | 2016-11-18 | 2016-11-22 | 89, 85 | 4.5d | 0d | Plumbing contractor | 16h |
| 91 | 8.5.4 | Conduct finish plumbing inspection | 1d | 2016-11-22 | 2016-11-23 | 90 | 4.5d | 0d | Inspector | 8h |
| 92 | 8.6 | **Finish Electrical** | 4d | 2016-11-22 | 2016-11-30 |  | 4.5d |  |  | 40h |
| 93 | 8.6.1 | Complete 1st floor circuits to service panel | 1d | 2016-11-22 | 2016-11-23 | 90, 58 | 4.5d | 0d | Electric contractor | 8h |
| 94 | 8.6.2 | Complete 2nd floor circuits to service panel | 1d | 2016-11-28 | 2016-11-29 | 93 | 6.5d | 0d | Electric contractor | 8h |
| 95 | 8.6.3 | Conduct finish electrical inspection | 1d | 2016-11-29 | 2016-11-30 | 94 | 6.5d | 2d | Inspector | 8h |
| 96 | 8.6.4 | Complete communications wiring - phone, cable, computer, alarm | 2d | 2016-11-23 | 2016-11-29 | 91 | 4.5d | 0d | Electric contractor | 16h |
| 97 | 8.7 | **Finish HVAC** | 3d | 2016-11-29 | 2016-12-02 |  | 4.5d |  |  | 24h |
| 98 | 8.7.1 | Complete 1st floor - zone 1 HVAC | 1d | 2016-11-29 | 2016-11-30 | 96, 60 | 4.5d | 0d | Heating and AC contractor | 8h |
| 99 | 8.7.2 | Complete 2nd floor - zone 2 HVAC | 1d | 2016-11-30 | 2016-12-01 | 98 | 4.5d | 0d | Heating and AC contractor | 8h |
| 100 | 8.7.3 | Conduct HVAC inspection | 1d | 2016-12-01 | 2016-12-02 | 99 | 4.5d | 0d | Inspector | 8h |
| 101 | 8.8 | **Carpet, Tile and Appliances** | 8d | 2016-12-02 | 2016-12-14 |  | 4.5d |  |  | 64h |
| 102 | 8.8.1 | Tile entry, kitchen and baths | 3d | 2016-12-02 | 2016-12-07 | 95, 100 | 4.5d | 0d | Flooring contractor | 24h |
| 103 | 8.8.2 | Carpet 1st floor | 2d | 2016-12-07 | 2016-12-09 | 102 | 4.5d | 0d | Flooring contractor | 16h |
| 104 | 8.8.3 | Carpet 2nd floor | 2d | 2016-12-09 | 2016-12-13 | 103 | 4.5d | 0d | Flooring contractor | 16h |
| 105 | 8.8.4 | Install appliances | 1d | 2016-12-13 | 2016-12-14 | 104 | 4.5d |  | Appliance contractor | 8h |
| 106 | 9 | **Landscaping and Grounds Work** | 14d | 2016-12-02 | 2016-12-21 |  | 0d |  |  | 104h |
| 107 | 9.1 | Pour concrete driveway and sidewalks | 1d | 2016-12-02 | 2016-12-02 | 81 | 0d |  | Concrete contractor [200%] | 16h |
| 108 | 9.2 | Install backyard fence | 2d | 2016-12-05 | 2016-12-06 | 107 | 0d |  | Fencing contractor | 16h |
| 109 | 9.3 | Order Plants and Trees | 1d | 2016-12-07 | 2016-12-07 | 108 | 0d |  | Gary Clark | 8h |
| 110 | 9.4 | Build Compost Bin | 1d | 2016-12-08 | 2016-12-08 | 109 | 0d |  | Gary Clark | 8h |
| 111 | 9.5 | Build Flower Beds and Edges | 2d | 2016-12-12 | 2016-12-13 | 110 | 0d |  | Gary Clark | 16h |
| 112 | 9.6 | Weed and Trim Existing Yard | 2d | 2016-12-14 | 2016-12-15 | 111 | 0d |  | Gary Clark | 16h |
| 113 | 9.7 | Plant New Plants and Trees | 2d | 2016-12-19 | 2016-12-20 | 112 | 0d |  | Gary Clark | 16h |
| 114 | 9.8 | Re-Seed Bare Lawn Areas | 1d | 2016-12-21 | 2016-12-21 | 113 | 5d |  | Gary Clark | 8h |

Notes:
- 106: Additional tasks provided by Gary Clark.

| ID | WBS | Task | Type | Duration | Start | Finish | Predecessors | Total slack | Deadline | Resources | Work | Cost |
| --- | --- | --- | --- | --- | --- | --- | --- | --- | --- | --- | --- | --- |
| 115 | 10 | **Final Acceptance** |  | 19.5d | 2016-12-02 | 2016-12-30 |  | 0d |  |  | 64h | 400 |
| 116 | 10.1 | Complete final inspection for certificate of occupancy |  | 1d | 2016-12-02 | 2016-12-05 | 100, 95, 91, 67, 86, 56 | 11.5d |  | Inspector | 8h |  |
| 117 | 10.2 | Cleanup for occupancy |  | 1d | 2016-12-21 | 2016-12-21 | 105, 116, 113 | 0d |  | Maid service | 8h | 400 |
| 118 | 10.3 | Perform final walk-through inspection |  | 1d | 2016-12-22 | 2016-12-22 | 117 | 0d |  | Owner | 8h |  |
| 119 | 10.4 | Complete punch list items |  | 5d | 2016-12-23 | 2016-12-30 | 118 | 0d |  | General contractor | 40h |  |
| 120 | 10.5 | Ready for Move-In | milestone | 0d | 2016-12-30 | 2016-12-30 | 119 | 0d | 2016-12-31 |  |  |  |
