# Woods Family 3BR Home

Schedule from MS Project, 2016-05-02 to 2017-01-03, status date 2016-09-23, costs in $, A marks actual dates.
Residential Construction
Building with Heart
Clear debris. Two girls. Greene City Interiors for finishing.

## Calendars

- BWH Standard Calendar: Mon-Fri 08:00-12:00, 13:00-17:00; Sat-Sun off. Exceptions (off unless hours are given): 2016-05-23 to 2025-05-26 (Memorial Day, recurring), 2016-07-04 (Independence Day), 2016-09-05 (Labor Day), 2016-11-08 08:00-12:00 (Election Day), 2016-11-24 (Thanksgiving Day), 2016-11-25 (Black Friday), 2016-12-26 (Christmas Day (observed)), 2017-01-02 (New Year's Day (observed)).

## Resources

| Resource | Unit | Rate |
| --- | --- | --- |
| Concrete contractor |  |  |
| Finish carpentry contractor |  |  |
| Fencing contractor |  |  |
| Masonry contractor |  |  |
| General contractor |  |  |
| Architect |  |  |
| Owner |  |  |
| Mortgage lender |  |  |
| Inspector |  |  |
| Electric company |  |  |
| Site excavation contractor |  |  |
| Electric contractor |  |  |
| Plumbing contractor |  |  |
| Framing contractor |  |  |
| Roofing contractor |  |  |
| Heating and AC contractor |  |  |
| Insulation contractor |  |  |
| Drywall contractor |  |  |
| Painting contractor |  |  |
| Flooring contractor |  |  |
| Appliance contractor |  |  |
| Gary Clark |  |  |
| Maid service |  | 40 |
| Volunteer 1 |  |  |
| Volunteer 2 |  |  |
| Volunteer 3 |  |  |
| Volunteer 4 |  |  |
| Container |  | 2.5 |
| Waste Dump Fee | ton | 150 |
| Construction Fixed Cost |  |  |
| Project Budget |  |  |

## Schedule

| ID | WBS | Task | Type | Duration | Start | Finish | Predecessors | Complete | Baseline start | Baseline finish | Baseline duration | Constraint | Resources | Work | Actual work | Cost | Baseline cost | Actual cost |
| --- | --- | --- | --- | --- | --- | --- | --- | --- | --- | --- | --- | --- | --- | --- | --- | --- | --- | --- |
| 1 | 1 | **General Conditions** |  | 45d? | 2016-05-02 A | 2016-07-05 A |  | 100% | 2016-05-02 | 2016-07-05 | 45d? |  | Construction Fixed Cost [0.1%] | 569.2h | 569.2h | 184,870 | 183,280 | 184,870 |
| 2 | 1.1 | Finalize plans and develop estimate with owner, architect |  | 10d | 2016-05-02 A | 2016-05-13 A |  | 100% | 2016-05-02 | 2016-05-13 | 10d |  | General contractor [50%]; Architect [50%]; Owner [12%]; Mortgage lender [12%] | 99.2h | 99.2h |  |  |  |
| 3 | 1.2 | Sign contract and notice to proceed |  | 1d | 2016-05-16 A | 2016-05-16 A | 2 | 100% | 2016-05-16 | 2016-05-16 | 1d |  | General contractor; Architect; Owner; Mortgage lender | 32h | 32h |  |  |  |
| 4 | 1.3 | **Clear Old Home** |  | 24d? | 2016-06-01 A | 2016-07-05 A |  | 100% | 2016-06-01 | 2016-07-05 | 24d? |  |  | 438h | 438h | 4,870 | 3,280 | 4,870 |
| 5 | 1.3.1 | Demolition of Old House |  | 2w? | 2016-06-01 A | 2016-06-14 A | 3FS+2w | 100% | 2016-06-01 | 2016-06-14 | 2w? |  | Site excavation contractor | 80h | 80h |  |  |  |
| 6 | 1.3.2 | Place Containers |  | 1d | 2016-06-01 A | 2016-06-01 A | 5SS | 100% | 2016-06-01 | 2016-06-01 | 1d |  | Container [300%]; Volunteer 4 | 24h | 24h | 60 | 40 | 60 |
| 7 | 1.3.3 | Sort Debris |  | 6.06d | 2016-06-09 A | 2016-06-17 A | 6, 5FF+1d | 100% | 2016-06-09 | 2016-06-15 | 5d |  | Volunteer 1; Volunteer 2; Volunteer 3; Volunteer 4; Container [300%] | 302h | 302h | 270 | 200 | 270 |
| 8 | 1.3.4 | Haul Recycling |  | 1d | 2016-07-05 A | 2016-07-05 A | 7 | 100% | 2016-07-05 | 2016-07-05 | 1d | start no earlier than 2016-07-05 | Container; Volunteer 4 | 16h | 16h | 20 | 20 | 20 |
| 9 | 1.3.5 | Haul Waste |  | 1d | 2016-06-17 A | 2016-06-20 A | 7 | 100% | 2016-06-16 | 2016-06-16 | 1d |  | Container; Volunteer 4; Waste Dump Fee [30 ton] | 16h | 16h | 4,520 | 3,020 | 4,520 |
| 10 | 1.4 | **Apply for Permits** |  | 9d | 2016-05-16 A | 2016-05-27 A |  | 100% | 2016-05-16 | 2016-05-16 | 0d |  |  |  |  |  |  |  |
| 11 | 1.4.1 | Secure foundation permit | milestone | 0d | 2016-05-16 A | 2016-05-27 A | 3 | 100% | 2016-05-16 | 2016-05-16 | 0d |  | General contractor |  |  |  |  |  |
| 12 | 1.4.2 | Secure framing permit | milestone | 0d | 2016-05-16 A | 2016-05-27 A | 3 | 100% | 2016-05-16 | 2016-05-16 | 0d |  | General contractor |  |  |  |  |  |
| 13 | 1.4.3 | Secure electrical permit | milestone | 0d | 2016-05-16 A | 2016-05-27 A | 3 | 100% | 2016-05-16 | 2016-05-16 | 0d |  | General contractor |  |  |  |  |  |
| 14 | 1.4.4 | Secure plumbing permit | milestone | 0d | 2016-05-16 A | 2016-05-27 A | 3 | 100% | 2016-05-16 | 2016-05-16 | 0d |  | General contractor |  |  |  |  |  |
| 15 | 1.4.5 | Secure HVAC permit | milestone | 0d | 2016-05-16 A | 2016-05-27 A | 3 | 100% | 2016-05-16 | 2016-05-16 | 0d |  | General contractor |  |  |  |  |  |
| 16 | 1.4.6 | Secure miscellaneous permits | milestone | 0d | 2016-05-16 A | 2016-05-27 A | 3 | 100% | 2016-05-16 | 2016-05-16 | 0d |  | General contractor |  |  |  |  |  |
| 17 | 2 | **Site Work** |  | 3d | 2016-07-06 A | 2016-07-08 A |  | 100% | 2016-07-06 | 2016-07-08 | 3d |  |  | 32h | 32h |  |  |  |
| 18 | 2.1 | Clear and grub lot |  | 1d | 2016-07-06 A | 2016-07-06 A | 11, 12, 13, 14, 16, 15, 8, 9 | 100% | 2016-07-06 | 2016-07-06 | 1d |  | Site excavation contractor | 8h | 8h |  |  |  |
| 19 | 2.2 | Install temporary power service |  | 1d | 2016-07-07 A | 2016-07-07 A | 18 | 100% | 2016-07-07 | 2016-07-07 | 1d |  | Electric company | 8h | 8h |  |  |  |
| 20 | 2.3 | Install underground utilities |  | 1d | 2016-07-08 A | 2016-07-08 A | 19 | 100% | 2016-07-08 | 2016-07-08 | 1d |  | Electric contractor; Plumbing contractor | 16h | 16h |  |  |  |
| 21 | 3 | **Foundation** |  | 27.5d | 2016-07-11 A | 2016-08-17 A |  | 100% | 2016-07-11 | 2016-08-17 | 27.5d |  |  | 280h | 280h |  |  |  |
| 22 | 3.1 | Excavate for foundations |  | 3d | 2016-07-11 A | 2016-07-13 A | 20 | 100% | 2016-07-11 | 2016-07-13 | 3d |  | Site excavation contractor | 24h | 24h |  |  |  |
| 23 | 3.2 | Form basement walls |  | 6.5d | 2016-07-14 A | 2016-07-22 A | 22 | 100% | 2016-07-14 | 2016-07-22 | 6.5d |  | Concrete contractor [200%] | 104h | 104h |  |  |  |
| 24 | 3.3 | Place concrete for foundations & basement walls |  | 6d | 2016-07-22 A | 2016-08-01 A | 23 | 100% | 2016-07-22 | 2016-08-01 | 6d |  | Concrete contractor [200%] | 96h | 96h |  |  |  |
| 25 | 3.4 | Cure basement walls for 7 days |  | 7d | 2016-08-01 A | 2016-08-10 A | 24 | 100% | 2016-08-01 | 2016-08-10 | 7d |  |  |  |  |  |  |  |
| 26 | 3.5 | Strip basement wall forms |  | 1d | 2016-08-10 A | 2016-08-11 A | 25 | 100% | 2016-08-10 | 2016-08-11 | 1d |  | Concrete contractor [200%] | 16h | 16h |  |  |  |
| 27 | 3.6 | Waterproof/insulate basement walls |  | 1d | 2016-08-11 A | 2016-08-12 A | 26 | 100% | 2016-08-11 | 2016-08-12 | 1d |  | Concrete contractor [200%] | 16h | 16h |  |  |  |
| 28 | 3.7 | Perform foundation inspection |  | 1d | 2016-08-12 A | 2016-08-15 A | 27, 22 | 100% | 2016-08-12 | 2016-08-15 | 1d |  | Inspector | 8h | 8h |  |  |  |
| 29 | 3.8 | Backfill foundation |  | 2d | 2016-08-15 A | 2016-08-17 A | 28 | 100% | 2016-08-15 | 2016-08-17 | 2d |  | Site excavation contractor | 16h | 16h |  |  |  |

| ID | WBS | Task | Duration | Start | Finish | Predecessors | Complete | Remaining | Baseline start | Baseline finish | Baseline duration | Total slack | Free slack | Constraint | Resources | Work | Actual work |
| --- | --- | --- | --- | --- | --- | --- | --- | --- | --- | --- | --- | --- | --- | --- | --- | --- | --- |
| 30 | 4 | **Framing** | 27.5d | 2016-08-17 A | 2016-09-26 |  | 96% | 1d | 2016-08-17 | 2016-09-19 | 22d | -0.5d | 0d |  |  | 220h | 212h |
| 31 | 4.1 | Install 1st floor joists | 2d | 2016-08-17 A | 2016-08-19 A | 29 | 100% |  | 2016-08-17 | 2016-08-19 | 2d |  |  |  | Framing contractor | 16h | 16h |
| 32 | 4.2 | Lay 1st floor decking | 2d | 2016-08-19 A | 2016-08-23 A | 31 | 100% |  | 2016-08-19 | 2016-08-23 | 2d |  |  |  | Framing contractor | 16h | 16h |
| 33 | 4.3 | Frame 1st floor walls | 4d | 2016-08-23 A | 2016-08-29 A | 32 | 100% |  | 2016-08-23 | 2016-08-29 | 4d |  |  |  | Framing contractor | 32h | 32h |
| 34 | 4.4 | Frame 1st floor corners | 1d | 2016-08-29 A | 2016-08-30 A | 33 | 100% |  | 2016-08-29 | 2016-08-30 | 1d |  |  |  | Framing contractor | 8h | 8h |
| 35 | 4.5 | Install 2nd floor joists | 2d | 2016-08-30 A | 2016-09-01 A | 34 | 100% |  | 2016-08-30 | 2016-09-01 | 2d |  |  |  | Framing contractor | 16h | 16h |
| 36 | 4.6 | Frame 2nd floor decking | 2d | 2016-09-01 A | 2016-09-06 A | 35 | 100% |  | 2016-09-01 | 2016-09-06 | 2d |  |  |  | Framing contractor | 16h | 16h |
| 37 | 4.7 | Frame 2nd floor walls | 3d | 2016-09-06 A | 2016-09-09 A | 36 | 100% |  | 2016-09-06 | 2016-09-09 | 3d |  |  |  | Framing contractor | 24h | 24h |
| 38 | 4.8 | Frame 2nd floor corners | 5.5d | 2016-09-09 A | 2016-09-16 A | 37 | 100% |  | 2016-09-09 | 2016-09-13 | 2d |  |  |  | Framing contractor | 44h | 44h |
| 39 | 4.9 | Complete roof framing | 5d | 2016-09-19 A | 2016-09-23 A | 38 | 100% |  | 2016-09-13 | 2016-09-16 | 3d |  |  |  | Framing contractor | 40h | 40h |
| 40 | 4.10 | Conduct framing inspection | 1d | 2016-09-26 | 2016-09-26 | 39 |  |  | 2016-09-16 | 2016-09-19 | 1d | -0.5d | 0d |  | Inspector | 8h |  |
| 41 | 5 | **Dry In** | 24d | 2016-09-26 | 2016-10-27 |  |  |  | 2016-09-16 | 2016-10-20 | 24d | -0.5d | 0d |  |  | 152h |  |
| 42 | 5.1 | Install 1st floor sheathing | 3d | 2016-09-27 | 2016-09-29 | 40 |  |  | 2016-09-19 | 2016-09-22 | 3d | -0.5d | 0d |  | Framing contractor | 24h |  |
| 43 | 5.2 | Install 2nd floor sheathing | 3d | 2016-10-04 | 2016-10-06 | 42 |  |  | 2016-09-26 | 2016-09-29 | 3d | -0.5d | 0d |  | Framing contractor | 24h |  |
| 44 | 5.3 | Install roof decking | 3d | 2016-09-26 | 2016-10-03 | 39 |  |  | 2016-09-16 | 2016-09-26 | 3d | 2.5d | 0d |  | Framing contractor | 24h |  |
| 45 | 5.4 | Install felt, flashing and shingles | 3d | 2016-10-14 | 2016-10-18 | 53 |  |  | 2016-10-06 | 2016-10-11 | 3d | -0.5d | 0d |  | Roofing contractor | 24h |  |
| 46 | 5.5 | Hang 1st floor exterior doors | 1d | 2016-10-19 | 2016-10-19 | 45 |  |  | 2016-10-11 | 2016-10-12 | 1d | -0.5d | 0d |  | Framing contractor | 8h |  |
| 47 | 5.6 | Install 1st floor windows | 3d | 2016-10-20 | 2016-10-24 | 46 |  |  | 2016-10-12 | 2016-10-17 | 3d | -0.5d | 0d |  | Framing contractor | 24h |  |
| 48 | 5.7 | Install 2nd floor windows | 3d | 2016-10-25 | 2016-10-27 | 47 |  |  | 2016-10-17 | 2016-10-20 | 3d | -0.5d | 0d |  | Framing contractor | 24h |  |
| 49 | 6 | **Exterior Finishes** | 19d | 2016-10-28 | 2016-11-28 |  |  |  | 2016-10-20 | 2016-11-16 | 19d | -0.5d | 0d |  |  | 152h |  |
| 50 | 6.1 | Complete exterior brick | 16d | 2016-10-28 | 2016-11-21 | 48 |  |  | 2016-10-20 | 2016-11-11 | 16d | -0.5d | 0d |  | Masonry contractor | 128h |  |
| 51 | 6.2 | Complete exterior siding | 3d | 2016-11-21 | 2016-11-28 | 50 |  |  | 2016-11-14 | 2016-11-16 | 3d | -0.5d | 0d |  | Framing contractor | 24h |  |
| 52 | 7 | **Utility Rough-B97Ins and Complete Concrete** | 21d | 2016-10-04 | 2016-11-01 |  |  |  | 2016-09-26 | 2016-11-01 | 26.5d | 2.5d |  |  |  | 232h |  |
| 53 | 7.1 | Rough-in plumbing | 5d | 2016-10-07 | 2016-10-13 | 44, 43 |  |  | 2016-09-29 | 2016-10-06 | 5d | -0.5d | 0d |  | Plumbing contractor | 40h |  |
| 54 | 7.2 | Conduct rough-in plumbing inspection | 1d | 2016-10-14 | 2016-10-14 | 53 |  |  | 2016-10-06 | 2016-10-07 | 1d | 25.5d | 0d |  | Inspector | 8h |  |
| 55 | 7.3 | Place concrete for basement floor | 5.5d | 2016-10-17 | 2016-10-24 | 54 |  |  | 2016-10-07 | 2016-10-14 | 5.5d | 38d | 29d |  | Concrete contractor [200%] | 88h |  |
| 56 | 7.4 | Rough-in electrical | 5d | 2016-10-07 | 2016-10-13 | 44, 43 |  |  | 2016-09-29 | 2016-10-06 | 5d | 11.5d | 8d |  | Electric contractor | 40h |  |
| 57 | 7.5 | Conduct rough-in electrical inspection | 1d | 2016-10-26 | 2016-10-26 | 56 |  |  | 2016-10-26 | 2016-10-26 | 1d | 3.5d | 0d | start no earlier than 2016-10-26 | Inspector | 8h |  |
| 58 | 7.6 | Rough-in HVAC | 3d | 2016-10-27 | 2016-10-31 | 57 |  |  | 2016-10-27 | 2016-10-31 | 3d | 3.5d | 0d |  | Heating and AC contractor | 24h |  |
| 59 | 7.7 | Conduct rough-in HVAC inspection | 1d | 2016-11-01 | 2016-11-01 | 58 |  |  | 2016-11-01 | 2016-11-01 | 1d | 21.5d | 18d |  | Inspector | 8h |  |
| 60 | 7.8 | Rough-in communication - phone, cable, computer, alarm | 2d | 2016-10-04 | 2016-10-05 | 44 |  |  | 2016-09-26 | 2016-09-28 | 2d | 21.5d | 18d |  | Electric contractor | 16h |  |

| ID | WBS | Task | Duration | Start | Finish | Predecessors | Baseline start | Baseline finish | Baseline duration | Total slack | Free slack | Resources | Work |
| --- | --- | --- | --- | --- | --- | --- | --- | --- | --- | --- | --- | --- | --- |
| 61 | 8 | **Interior Finishes** | 31.5d | 2016-11-01 | 2016-12-16 |  | 2016-11-01 | 2016-12-16 | 31.5d | 3.5d |  |  | 408h |
| 62 | 8.1 | **Insulation** | 11.5d | 2016-11-01 | 2016-11-16 |  | 2016-11-01 | 2016-11-16 | 11.5d | 3.5d |  |  | 32h |
| 63 | 8.1.1 | Place wall insulation - 1st floor | 1d | 2016-11-01 | 2016-11-01 | 42, 48, 60, 58, 56, 43 | 2016-11-01 | 2016-11-01 | 1d | 3.5d | 0d | Insulation contractor | 8h |
| 64 | 8.1.2 | Place wall insulation - 2nd floor | 1d | 2016-11-02 | 2016-11-02 | 63 | 2016-11-02 | 2016-11-02 | 1d | 24.5d | 3d | Insulation contractor | 8h |
| 65 | 8.1.3 | Place ceiling insulation - 2nd floor | 1d | 2016-11-15 | 2016-11-15 | 71, 64 | 2016-11-15 | 2016-11-15 | 1d | 21d | 0d | Insulation contractor | 8h |
| 66 | 8.1.4 | Conduct insulation inspection | 1d | 2016-11-16 | 2016-11-16 | 65 | 2016-11-16 | 2016-11-16 | 1d | 21d | 12d | Inspector | 8h |
| 67 | 8.2 | **Drywall** | 9.5d | 2016-11-02 | 2016-11-15 |  | 2016-11-02 | 2016-11-15 | 9.5d | 3.5d |  |  | 80h |
| 68 | 8.2.1 | Install drywall - 1st floor walls | 2d | 2016-11-02 | 2016-11-03 | 63 | 2016-11-02 | 2016-11-03 | 2d | 3.5d | 0d | Drywall contractor | 16h |
| 69 | 8.2.2 | Install drywall - 1st floor overhead | 2d | 2016-11-04 | 2016-11-07 | 68 | 2016-11-04 | 2016-11-07 | 2d | 3.5d | 0d | Drywall contractor | 16h |
| 70 | 8.2.3 | Install drywall 2nd floor walls | 2d | 2016-11-09 | 2016-11-10 | 69, 64 | 2016-11-09 | 2016-11-10 | 2d | 21d | 0d | Drywall contractor | 16h |
| 71 | 8.2.4 | Install drywall 2nd floor overhead | 2d | 2016-11-11 | 2016-11-14 | 70 | 2016-11-11 | 2016-11-14 | 2d | 21d | 0d | Drywall contractor | 16h |
| 72 | 8.2.5 | Tape and float 1st floor drywall | 1d | 2016-11-08 | 2016-11-09 | 69 | 2016-11-08 | 2016-11-09 | 1d | 3.5d | 0d | Drywall contractor | 8h |
| 73 | 8.2.6 | Tape and float 2nd floor drywall | 1d | 2016-11-15 | 2016-11-15 | 71, 72 | 2016-11-15 | 2016-11-15 | 1d | 30.5d |  | Drywall contractor | 8h |
| 74 | 8.3 | **Paint and Wallpaper** | 15d | 2016-11-09 | 2016-12-02 |  | 2016-11-09 | 2016-11-22 | 9.5d | 3.5d |  |  | 72h |
| 75 | 8.3.1 | Texture all except entry and kitchen - 1st floor | 1d | 2016-11-09 | 2016-11-10 | 72 | 2016-11-09 | 2016-11-10 | 1d | 3.5d | 0d | Painting contractor | 8h |
| 76 | 8.3.2 | Paint all except entry and kitchen - 1st floor | 1d | 2016-11-10 | 2016-11-11 | 75 | 2016-11-10 | 2016-11-11 | 1d | 3.5d | 0d | Painting contractor | 8h |
| 77 | 8.3.3 | Hang wallpaper entry and kitchen - 1st floor | 1d | 2016-11-11 | 2016-11-14 | 76 | 2016-11-11 | 2016-11-14 | 1d | 3.5d | 0d | Painting contractor | 8h |
| 78 | 8.3.4 | Texture all - 2nd floor | 1d | 2016-11-14 | 2016-11-15 | 75 | 2016-11-14 | 2016-11-15 | 1d | 30d | 0d | Painting contractor | 8h |
| 79 | 8.3.5 | Paint all - 2nd floor | 1d | 2016-11-15 | 2016-11-16 | 78 | 2016-11-15 | 2016-11-16 | 1d | 30d |  | Painting contractor | 8h |
| 80 | 8.3.6 | Paint exterior siding & trim work | 4d | 2016-11-28 | 2016-12-02 | 51 | 2016-11-17 | 2016-11-22 | 4d | -0.5d | 0d | Painting contractor | 32h |
| 81 | 8.4 | **Cabinets** | 6d | 2016-11-14 | 2016-11-22 |  | 2016-11-14 | 2016-11-22 | 6d | 3.5d |  |  | 48h |
| 82 | 8.4.1 | Install 1st floor - kitchen cabinets | 2d | 2016-11-14 | 2016-11-16 | 77 | 2016-11-14 | 2016-11-16 | 2d | 3.5d | 0d | Finish carpentry contractor | 16h |
| 83 | 8.4.2 | Install 1st floor - master bath and guest cabinets | 1d | 2016-11-16 | 2016-11-17 | 82 | 2016-11-16 | 2016-11-17 | 1d | 3.5d | 0d | Finish carpentry contractor | 8h |
| 84 | 8.4.3 | Install 2nd floor - hall bath and private bath cabinets | 1d | 2016-11-17 | 2016-11-18 | 83 | 2016-11-17 | 2016-11-18 | 1d | 4.5d | 0d | Finish carpentry contractor | 8h |
| 85 | 8.4.4 | Install chair rails, crown moldings, trim | 2d | 2016-11-18 | 2016-11-22 | 84 | 2016-11-18 | 2016-11-22 | 2d | 17.5d | 8.5d | Finish carpentry contractor | 16h |

| ID | WBS | Task | Duration | Start | Finish | Predecessors | Baseline start | Baseline finish | Baseline duration | Total slack | Free slack | Resources | Work |
| --- | --- | --- | --- | --- | --- | --- | --- | --- | --- | --- | --- | --- | --- |
| 86 | 8.5 | **Finish Plumbing** | 6d | 2016-11-16 | 2016-11-28 |  | 2016-11-16 | 2016-11-28 | 6d | 3.5d |  |  | 48h |
| 87 | 8.5.1 | Complete 1st floor - kitchen plumbing | 1d | 2016-11-16 | 2016-11-17 | 82, 54 | 2016-11-16 | 2016-11-17 | 1d | 3.5d | 0d | Plumbing contractor | 8h |
| 88 | 8.5.2 | Complete 1st floor - master bath and guest plumbing | 2d | 2016-11-17 | 2016-11-21 | 87, 83 | 2016-11-17 | 2016-11-21 | 2d | 3.5d | 0d | Plumbing contractor | 16h |
| 89 | 8.5.3 | Complete 2nd floor - hall bath and private bath plumbing | 2d | 2016-11-21 | 2016-11-23 | 88, 84 | 2016-11-21 | 2016-11-23 | 2d | 3.5d | 0d | Plumbing contractor | 16h |
| 90 | 8.5.4 | Conduct finish plumbing inspection | 1d | 2016-11-23 | 2016-11-28 | 89 | 2016-11-23 | 2016-11-28 | 1d | 3.5d | 0d | Inspector | 8h |
| 91 | 8.6 | **Finish Electrical** | 7.5d | 2016-11-23 | 2016-12-06 |  | 2016-11-23 | 2016-12-06 | 7.5d | 2d |  |  | 40h |
| 92 | 8.6.1 | Complete 1st floor circuits to service panel | 1d | 2016-11-23 | 2016-11-28 | 89, 57 | 2016-11-23 | 2016-11-28 | 1d | 3.5d | 1.5d | Electric contractor | 8h |
| 93 | 8.6.2 | Complete 2nd floor circuits to service panel | 1d | 2016-12-05 | 2016-12-05 | 92 | 2016-12-05 | 2016-12-05 | 1d | 2d | 0d | Electric contractor | 8h |
| 94 | 8.6.3 | Conduct finish electrical inspection | 1d | 2016-12-06 | 2016-12-06 | 93 | 2016-12-06 | 2016-12-06 | 1d | 2d | 0d | Inspector | 8h |
| 95 | 8.6.4 | Complete communications wiring - phone, cable, computer, alarm | 2d | 2016-11-28 | 2016-11-30 | 90 | 2016-11-28 | 2016-11-30 | 2d | 3.5d | 0d | Electric contractor | 16h |
| 96 | 8.7 | **Finish HVAC** | 3d | 2016-11-30 | 2016-12-05 |  | 2016-11-30 | 2016-12-05 | 3d | 3.5d |  |  | 24h |
| 97 | 8.7.1 | Complete 1st floor - zone 1 HVAC | 1d | 2016-11-30 | 2016-12-01 | 95, 59 | 2016-11-30 | 2016-12-01 | 1d | 3.5d | 0d | Heating and AC contractor | 8h |
| 98 | 8.7.2 | Complete 2nd floor - zone 2 HVAC | 1d | 2016-12-01 | 2016-12-02 | 97 | 2016-12-01 | 2016-12-02 | 1d | 3.5d | 0d | Heating and AC contractor | 8h |
| 99 | 8.7.3 | Conduct HVAC inspection | 1d | 2016-12-02 | 2016-12-05 | 98 | 2016-12-02 | 2016-12-05 | 1d | 3.5d | 1.5d | Inspector | 8h |
| 100 | 8.8 | **Carpet, Tile and Appliances** | 8d | 2016-12-07 | 2016-12-16 |  | 2016-12-07 | 2016-12-16 | 8d | 2d |  |  | 64h |
| 101 | 8.8.1 | Tile entry, kitchen and baths | 3d | 2016-12-07 | 2016-12-09 | 94, 99 | 2016-12-07 | 2016-12-09 | 3d | 2d | 0d | Flooring contractor | 24h |
| 102 | 8.8.2 | Carpet 1st floor | 2d | 2016-12-12 | 2016-12-13 | 101 | 2016-12-12 | 2016-12-13 | 2d | 2d | 0d | Flooring contractor | 16h |
| 103 | 8.8.3 | Carpet 2nd floor | 2d | 2016-12-14 | 2016-12-15 | 102 | 2016-12-14 | 2016-12-15 | 2d | 2d | 0d | Flooring contractor | 16h |
| 104 | 8.8.4 | Install appliances | 1d | 2016-12-16 | 2016-12-16 | 103 | 2016-12-16 | 2016-12-16 | 1d | 2d |  | Appliance contractor | 8h |
| 105 | 9 | **Landscaping and Grounds Work** | 14d | 2016-12-02 | 2016-12-22 |  | 2016-11-23 | 2016-12-14 | 14d | -0.5d | 0d |  | 104h |
| 106 | 9.1 | Pour concrete driveway and sidewalks | 1d | 2016-12-02 | 2016-12-05 | 80 | 2016-11-23 | 2016-11-23 | 1d | -0.5d | 0d | Concrete contractor [200%] | 16h |
| 107 | 9.2 | Install backyard fence | 2d | 2016-12-05 | 2016-12-07 | 106 | 2016-11-28 | 2016-11-29 | 2d | -0.5d | 0d | Fencing contractor | 16h |
| 108 | 9.3 | Order Plants and Trees | 1d | 2016-12-07 | 2016-12-08 | 107 | 2016-11-30 | 2016-11-30 | 1d | -0.5d | 0d | Gary Clark | 8h |
| 109 | 9.4 | Build Compost Bin | 1d | 2016-12-08 | 2016-12-12 | 108 | 2016-12-01 | 2016-12-01 | 1d | -1.5d | 0d | Gary Clark | 8h |
| 110 | 9.5 | Build Flower Beds and Edges | 2d | 2016-12-12 | 2016-12-14 | 109 | 2016-12-05 | 2016-12-06 | 2d | -0.5d | 0d | Gary Clark | 16h |
| 111 | 9.6 | Weed and Trim Existing Yard | 2d | 2016-12-14 | 2016-12-19 | 110 | 2016-12-07 | 2016-12-08 | 2d | -1.5d | 0d | Gary Clark | 16h |
| 112 | 9.7 | Plant New Plants and Trees | 2d | 2016-12-19 | 2016-12-21 | 111 | 2016-12-12 | 2016-12-13 | 2d | -0.5d | 0d | Gary Clark | 16h |
| 113 | 9.8 | Re-Seed Bare Lawn Areas | 1d | 2016-12-21 | 2016-12-22 | 112 | 2016-12-14 | 2016-12-14 | 1d | 5d |  | Gary Clark | 8h |

Notes:
- 105: Additional tasks provided by Gary Clark.

| ID | WBS | Task | Type | Duration | Start | Finish | Predecessors | Baseline start | Baseline finish | Baseline duration | Total slack | Free slack | Deadline | Resources | Work | Cost | Baseline cost |
| --- | --- | --- | --- | --- | --- | --- | --- | --- | --- | --- | --- | --- | --- | --- | --- | --- | --- |
| 114 | 10 | **Final Acceptance** |  | 17.5d | 2016-12-07 | 2017-01-03 |  | 2016-12-07 | 2016-12-28 | 15d | -0.5d | 0d |  |  | 64h | 400 | 400 |
| 115 | 10.1 | Complete final inspection for certificate of occupancy |  | 1d | 2016-12-07 | 2016-12-07 | 99, 94, 90, 66, 85, 55 | 2016-12-07 | 2016-12-07 | 1d | 9d |  |  | Inspector | 8h |  |  |
| 116 | 10.2 | Cleanup for occupancy |  | 1d | 2016-12-21 | 2016-12-22 | 104, 115, 112 | 2016-12-19 | 2016-12-19 | 1d | -0.5d | 0d |  | Maid service | 8h | 400 | 400 |
| 117 | 10.3 | Perform final walk-through inspection |  | 1d | 2016-12-22 | 2016-12-23 | 116 | 2016-12-20 | 2016-12-20 | 1d | -0.5d | 0d |  | Owner | 8h |  |  |
| 118 | 10.4 | Complete punch list items |  | 5d | 2016-12-23 | 2017-01-03 | 117 | 2016-12-21 | 2016-12-28 | 5d | -0.5d | 0d |  | General contractor | 40h |  |  |
| 119 | 10.5 | Ready for Move-In | milestone | 0d | 2017-01-03 | 2017-01-03 | 118 | 2016-12-28 | 2016-12-28 | 0d | -0.5d | 0d | 2016-12-31 |  |  |  |  |
